# working schedule_CDMP_Agreement

Schedule from MS Project, 2011-03-20 to 2013-09-12, status date 2011-09-19, costs in $, A marks actual dates.
udd

## Calendars

- Standard: Mon-Thu 09:00-17:00; Fri-Sat off; Sun 09:00-17:00. Exceptions (off unless hours are given): 2011-05-25 09:00-17:00, 2011-06-12 to 2011-06-13 09:00-17:00, 2011-06-29 09:00-17:00, 2011-07-17, 2011-08-15, 2011-08-22, 2011-08-28, 2011-08-30 to 2011-09-01, 2011-10-06, 2011-11-06 to 2011-11-08, 2011-12-06, 2011-12-25, 2012-01-07 09:00-17:00, 2012-01-12 09:00-12:00, 2012-02-21, 2012-03-17, 2012-03-26, 2012-04-14, 2012-05-01, 2012-08-15, 2012-08-22, 2012-10-06, 2012-12-16, 2012-12-25, 2013-02-21, 2013-03-17, 2013-03-26, 2013-04-14, 2013-08-15, 2013-08-22.

## Resources

| Resource | Rate |
| --- | --- |
| CDMP |  |
| Taufique |  |
| Akhtar |  |
| Fazlul |  |
| Shaheen |  |
| Tariq |  |
| Uday |  |
| Mahamud |  |
| Nurul |  |
| Habib |  |
| Yearunnessa |  |
| Shafique |  |
| Borhan |  |
| Mokles |  |
| Alim |  |
| Hakim |  |
| Anis |  |
| Shariful |  |
| Chancal |  |
| Monir |  |
| Maksuda |  |
| Abu Bakkar |  |
| Sohel |  |
| Nazrul |  |
| Raju |  |
| Badrul |  |
| Siddiquei |  |
| Survey Expert | 468.75 |
| GIS/RS Expert | 468.75 |
| Jr.GIS/RS Expert | 468.75 |
| Transport planner | 375 |
| Geologist | 468.75 |
| Urban Economist | 468.75 |
| Statistician | 468.75 |
| Environmetal Expert | 468.75 |
| Participatory Expert | 468.75 |
| CADD Operator | 468.75 |
| Consulting Firm by CDMP |  |
| UDD |  |
| Consultanting Firm by UDD |  |

## Schedule

| ID | WBS | Task | Type | Duration | Start | Finish | Predecessors | Complete | Remaining | Total slack | Free slack | Constraint | Deadline | Resources | Work | Actual work |
| --- | --- | --- | --- | --- | --- | --- | --- | --- | --- | --- | --- | --- | --- | --- | --- | --- |
| 1 | 1 | MOU |  | 1d | 2011-03-20 A | 2011-03-20 A |  | 100% |  |  |  | start no earlier than 2011-03-20 | 2011-03-20 | CDMP; UDD | 16h | 16h |
| 2 | 2 | Budget Approval |  | 16d | 2011-03-21 A | 2011-04-11 A | 1 | 100% |  |  |  | start no earlier than 2011-03-22 |  |  |  |  |
| 3 | 3 | Financial Agreement signing | milestone | 1d | 2011-04-12 A | 2011-04-12 A | 2 | 100% |  |  |  | start no earlier than 2011-04-12 |  | CDMP; UDD | 16h | 16h |
| 4 | 4 | Selection of Firm (Physical feature survey) by CDMP |  | 44d? | 2011-07-19 | 2011-09-26 | 3 |  |  | 29.38d | 0d | start no earlier than 2011-07-19 |  | CDMP | 352h |  |
| 5 | 5 | Notification of Award by CDMP |  | 5d? | 2011-09-27 | 2011-10-03 | 4 |  |  | 29.38d | 0d | finish no earlier than 2011-05-16 |  | CDMP | 40h |  |
| 6 | 6 | Digitzation from Satellite Image by Consulting Firm |  | 21d? | 2011-10-04 | 2011-11-02 | 5 |  |  | 29.38d | 0d | finish no earlier than 2011-10-25 |  | Consulting Firm by CDMP | 168h |  |
| 7 | 7 | Mobilization & Logistic for Survey firm |  | 10d? | 2011-11-03 | 2011-11-21 | 5, 4, 6 |  |  | 29.38d | 0d | start no earlier than 2011-09-26 |  | Consulting Firm by CDMP | 80h |  |
| 8 | 8 | Construction & Establishment of BM Pillars |  | 5d? | 2011-11-03 | 2011-11-14 | 5, 7SS |  |  | 50.38d | 7d | start no earlier than 2011-10-10 |  | Consulting Firm by CDMP | 40h |  |
| 9 | 9 | Detailed Physical feature & land use survey of Mymensing municipality area |  | 120d | 2011-11-03 | 2012-04-29 | 7SS |  |  | 29.38d | 0d | start no earlier than 2011-11-01 |  | Consulting Firm by CDMP | 960h |  |
| 10 | 10 | Preparing the Database of Acquired Data |  | 90d | 2011-12-29 | 2012-05-07 | 8, 9SS+35d |  |  | 14.38d | 0d | start no earlier than 2011-12-11 |  | Consulting Firm by CDMP | 720h |  |
| 11 | 11 | Handed over data of Mymensing municipality to UDD by CDMP |  | 25d | 2012-04-09 | 2012-05-15 | 10SS+71d |  |  | 96.38d | 0d | start no earlier than 2012-03-04 |  | CDMP | 200h |  |
| 12 | 12 | Completion of Physical Feature Survey | milestone | 0d | 2012-05-15 | 2012-05-15 | 11FF |  |  | 334.38d |  |  |  |  |  |  |
| 13 | 13 | Analysis of physical feature data focusing Earthquake |  | 65d? | 2012-05-07 | 2012-08-06 | 10 |  |  | 14.38d | 0d | start no earlier than 2012-03-28 |  | CDMP | 520h |  |
| 14 | 14 | **Post Planning Period** |  | 517.38d? | 2011-05-10 A | 2013-06-04 |  | 1% | 514.08d? | 70d |  |  |  |  | 11088h | 96h |
| 15 | 14.1 | Opening Bank Account for the Drector of UDD (Starting of UDD Part Activities) | milestone | 1d | 2011-05-10 A | 2011-05-10 A | 3 | 100% |  |  |  |  |  | UDD | 8h | 8h |
| 16 | 14.2 | Transfer of Fund from CDMP | milestone | 1d | 2011-06-21 A | 2011-06-21 A | 15 | 100% |  |  |  | start no earlier than 2011-06-21 |  | CDMP | 8h | 8h |
| 17 | 14.3 | Collection of Mouza Map of Mymensing municipality by UDD |  | 20d? | 2011-09-04 A | 2011-09-29 | 16 | 50% | 10d? | 363.38d | 0d | start no earlier than 2011-09-04 |  | UDD | 160h | 80h |
| 18 | 14.4 | Training (GIS/RS) for UDD by CDMP consultants |  | 44d? | 2011-10-02 | 2011-12-07 | 16, 17 |  |  | 363.38d | 0d | start no earlier than 2011-09-12 |  | CDMP | 352h |  |
| 19 | 14.5 | Digitization of Mouza map by UDD |  | 120d | 2011-10-02 | 2012-03-27 | 17, 18SS |  |  | 363.38d | 0d | start no earlier than 2011-10-02 |  |  |  |  |
| 20 | 14.6 | Completion of Mouza Map Digitization | milestone | 0d | 2012-03-27 | 2012-03-27 | 19 |  |  | 368.38d |  |  |  |  |  |  |
| 21 | 14.7 | Deployment of surveyors & officers to supervise and Checking physical feature survey, Land use and Social Space |  | 120d? | 2011-11-01 | 2012-04-25 |  |  |  | 350.38d |  | start no earlier than 2011-11-01 |  | Akhtar; Fazlul; Nurul; Borhan; Mahamud; Alim; Hakim; Anis; Shariful; Chancal; Habib | 10560h |  |
| 22 | 14.8 | **Manning Schedule for Individual Consultants** |  | 360.38d? | 2012-01-03 | 2013-06-04 |  |  |  | 70d |  |  |  |  |  |  |
| 23 | 14.8.1 | Survey Expert |  | 180d? | 2012-01-03 | 2012-09-17 | 104 |  |  | 247.38d |  | start no earlier than 2011-11-17 |  |  |  |  |
| 24 | 14.8.2 | GIS/RS Consultant-1 person (Mouza map digitization and survey) |  | 180d? | 2012-01-03 | 2012-09-17 | 104 |  |  | 247.38d |  | start no earlier than 2011-11-17 |  |  |  |  |
| 25 | 14.8.3 | GIS/RS Consultant-1 person (Planning Period) |  | 180d? | 2012-09-18 | 2013-06-04 | 104 |  |  | 67d |  | start no earlier than 2012-09-18 |  |  |  |  |
| 26 | 14.8.4 | Junior GIS/RS Expert |  | 180d? | 2012-09-18 | 2013-06-04 | 104 |  |  | 67d |  | start no earlier than 2012-09-18 |  |  |  |  |
| 27 | 14.8.5 | CADD Operator-1 person (Mouza Map digitization and survey) |  | 180d? | 2012-01-03 | 2012-09-17 | 104, 8SS |  |  | 247.38d |  | start no earlier than 2011-11-17 |  |  |  |  |
| 28 | 14.8.6 | CADD Operator-2 persons (Planning Period) |  | 180d? | 2012-09-18 | 2013-06-04 | 104 |  |  | 67d |  | start no earlier than 2012-09-18 |  |  |  |  |
| 29 | 14.8.7 | Transport Planner |  | 120d? | 2012-01-03 | 2012-10-24 |  |  |  | 220.38d |  | start no earlier than 2012-01-03 |  |  |  |  |
| 30 | 14.8.8 | Geologist |  | 80d? | 2012-01-03 | 2012-09-25 |  |  |  | 244.38d |  | start no earlier than 2012-01-03 |  |  |  |  |
| 31 | 14.8.9 | Statistictian |  | 80d? | 2012-04-01 | 2012-08-27 |  |  |  | 265d |  | start no earlier than 2012-04-01 |  |  |  |  |
| 32 | 14.8.10 | Environment Expert |  | 60d? | 2012-07-01 | 2012-09-24 |  |  |  | 242d |  | start no earlier than 2012-07-01 |  |  |  |  |
| 33 | 14.8.11 | Urban Economist |  | 80d? | 2012-08-01 | 2012-11-22 |  |  |  | 199d |  | start no earlier than 2012-08-01 |  |  |  |  |
| 34 | 14.8.12 | Paticipatory Expert |  | 80d? | 2012-01-03 | 2012-09-30 |  |  |  | 241.38d |  | start no earlier than 2012-01-03 |  |  |  |  |

Notes:
- 34: PRA Session 2

| ID | WBS | Task | Type | Duration | Start | Finish | Predecessors | Total slack | Free slack | Constraint | Resources | Work | Cost |
| --- | --- | --- | --- | --- | --- | --- | --- | --- | --- | --- | --- | --- | --- |
| 35 | 15 | **Plan Preparation Period (Phase-01)** |  | 505.38d? | 2011-09-04 | 2013-09-04 |  | 11d |  |  |  | 39288h | 6,180,833.25 |
| 36 | 15.1 | Collecting secondary data of Mymensing municipality |  | 60d? | 2011-09-04 | 2011-11-30 | 16 | 451.38d | 44d | start no earlier than 2011-09-04 | UDD | 480h |  |
| 37 | 15.2 | Digitization of master plan of Mymensing prepared in 1980 by LGED |  | 42.22d? | 2011-11-27 | 2012-01-25 | 18SS | 410.15d |  | start no earlier than 2011-11-27 | Abu Bakkar; Badrul; CADD Operator; Maksuda; Monir; Nazrul; Raju; Siddiquei; Sohel | 608h | 15,833.25 |
| 38 | 15.3 | Analysis of secondary data |  | 25d? | 2011-11-09 | 2011-12-14 | 36SS | 439.38d | 0d | start no earlier than 2011-11-09 | Akhtar; Fazlul; Habib; Mahamud; Shafique; Shaheen; Uday; Tariq; Yearunnessa; Environmetal Expert; Geologist; Statistician | 2400h | 281,250 |
| 39 | 15.4 | Completion of Secondary Data Analysis | milestone | 0d | 2011-12-14 | 2011-12-14 | 38 | 439.38d |  |  |  |  |  |
| 40 | 15.5 | Participatory Rural/Urban Appraisal (PRA), Session-01 |  | 5d? | 2012-03-04 | 2012-03-08 | 9SS+42d | 383d |  | start no earlier than 2012-03-04 | Akhtar; Participatory Expert; Shafique; Taufique; Fazlul; Yearunnessa | 240h | 18,750 |
| 41 | 15.6 | Workshop -01 (First public consultation at Mymensing) |  | 5d? | 2011-11-21 | 2011-11-27 | 38SS | 451.38d | 0d | finish no earlier than 2011-11-27 | Akhtar; Fazlul; CDMP; Mahamud; Taufique; Habib; Yearunnessa; Shafique | 320h |  |
| 42 | 15.7 | People's view and indentification of problems and prospets for development | milestone | 0d | 2011-11-27 | 2011-11-27 | 41 | 451.38d |  |  |  |  |  |
| 43 | 15.8 | Housing WP-01 Discussion |  | 20d? | 2011-09-25 | 2011-10-23 |  | 453.38d | 9d | start no earlier than 2011-09-25 | Mahamud | 160h |  |
| 44 | 15.9 | Land Use & Spatial Quality WP-02 Discussion |  | 20d? | 2011-10-09 | 2011-11-03 |  | 444.38d | 19d | start no earlier than 2011-10-09 | Fazlul | 160h |  |
| 45 | 15.10 | Hydrology WP-03 Dicussion |  | 20d? | 2011-10-23 | 2011-11-22 |  | 434.38d | 19d | start no earlier than 2011-10-23 | Fazlul | 160h |  |
| 46 | 15.11 | Transportation WP-04 Discussion |  | 10d? | 2011-11-13 | 2011-11-24 |  | 432.38d | 26d | start no earlier than 2011-11-13 | Nurul; Transport planner | 160h | 30,000 |
| 47 | 15.12 | Urban Economics WP-05 Discussion |  | 15d? | 2011-12-04 | 2011-12-26 |  | 417.38d | 7d | start no earlier than 2011-12-04 | Urban Economist | 120h | 56,250 |
| 48 | 15.13 | Population WP-06 Discussion |  | 20d? | 2011-12-07 | 2012-01-04 |  | 405.38d | 19.38d | start no earlier than 2011-12-07 | Statistician; Shafique; Yearunnessa; Akhtar | 640h | 75,000 |
| 49 | 15.14 | Disaster management WP-07 Discussion |  | 15d? | 2011-12-18 | 2012-01-07 |  | 403.38d | 27.38d | start no earlier than 2011-12-18 | Fazlul; Environmetal Expert | 240h | 56,250 |
| 50 | 15.15 | Housing WP-01 Recommendation |  | 20d? | 2011-11-09 | 2011-12-07 | 43 | 444.38d |  | start no earlier than 2011-11-06 |  |  |  |
| 51 | 15.16 | Land Use & Spatial Quality WP-02 Recommendation |  | 20d? | 2011-12-07 | 2012-01-04 | 44 | 425.38d |  | start no earlier than 2011-12-07 |  |  |  |
| 52 | 15.17 | Hydrology WP-03 Recommendation |  | 20d? | 2011-12-21 | 2012-01-18 | 45 | 423.38d |  | start no earlier than 2011-12-21 |  |  |  |
| 53 | 15.18 | Transportation WP-04 Recommendation |  | 20d? | 2012-01-04 | 2012-01-31 | 46 | 406.38d |  | start no earlier than 2012-01-04 |  |  |  |
| 54 | 15.19 | Urban Economics WP-05 recommendation |  | 15d? | 2012-01-05 | 2012-01-25 | 47 | 410.38d |  | start no earlier than 2012-01-05 |  |  |  |
| 55 | 15.20 | Population WP-06 Recommendation |  | 20d? | 2012-02-01 | 2012-02-29 | 48 | 386d |  | start no earlier than 2012-02-01 |  |  |  |
| 56 | 15.21 | Disaster management WP-07 Recommendation |  | 20d? | 2012-02-15 | 2012-03-14 | 49 | 376d |  | start no earlier than 2012-02-15 |  |  |  |
| 57 | 15.22 | Socio-Economic Survey conducting |  | 48d? | 2012-02-08 | 2012-04-17 | 9FS-60d | 53d | 0d | start no earlier than 2012-02-08 | Akhtar; Shafique; Yearunnessa; Mahamud; Mokles | 1920h |  |
| 58 | 15.23 | Participatory Rural/Urban Appraisal (PRA), session-02 |  | 5d? | 2012-03-18 | 2012-03-22 | 57SS+10d | 373d |  | finish no earlier than 2012-03-22 | Akhtar; Participatory Expert; Shafique; Yearunnessa; Fazlul; Taufique | 240h | 18,750 |
| 59 | 15.24 | Computing of socio-economic data |  | 20d? | 2012-04-16 | 2012-05-14 | 57SS+46d | 53d | 0d | start no earlier than 2011-11-20 | Yearunnessa; Akhtar; Mahamud; Shafique; Statistician; Mokles | 960h | 75,000 |
| 60 | 15.25 | Participatory Rural/Urban Appraisal (PRA), session-03 |  | 5d? | 2012-08-12 | 2012-08-20 | 57FS+5d, 69SS-6d | 266.38d |  | start no earlier than 2012-07-22 | Participatory Expert; Shafique; Yearunnessa; Akhtar; Fazlul; Taufique | 240h | 18,750 |
| 61 | 15.26 | Finalization of socio-economic database |  | 20d? | 2012-06-14 | 2012-07-11 | 59SS+42d | 53d | 0d | start no earlier than 2012-03-12 | Yearunnessa; Akhtar; Mahamud; Shafique; Statistician; Mokles | 960h | 75,000 |
| 62 | 15.27 | Recommendation from Socio-Economic survey |  | 15d? | 2012-07-09 | 2012-07-29 | 61SS+17d | 53d | 0d | start no earlier than 2012-04-05 | Shafique; Akhtar; Mahamud; Statistician; Yearunnessa; Mokles | 720h | 56,250 |
| 63 | 15.28 | Identification of Socio-Economic Condition of the Study Area | milestone | 0d | 2012-07-29 | 2012-07-29 | 62 | 289d |  | start no earlier than 2012-04-30 |  |  |  |
| 64 | 15.29 | Workshop -02 (Second public consultation at Mymensing) |  | 5d? | 2012-07-30 | 2012-08-05 | 62 | 284d | 0d | start no earlier than 2012-05-01 | Yearunnessa; Akhtar; Fazlul; Mahamud; Shafique; Statistician; Taufique | 280h | 18,750 |
| 65 | 15.30 | Discimination of Socio-Economic Situation of the Study Area | milestone | 0d | 2012-08-05 | 2012-08-05 | 64 | 284d |  |  |  |  |  |

| ID | WBS | Task | Type | Duration | Start | Finish | Predecessors | Total slack | Free slack | Constraint | Resources | Work | Cost |
| --- | --- | --- | --- | --- | --- | --- | --- | --- | --- | --- | --- | --- | --- |
| 66 | 15.31 | **Plan Preparation Period (Phase 02)** |  | 497.38d? | 2011-09-14 | 2013-09-04 |  | 11d |  |  |  | 28280h | 5,385,000 |
| 67 | 15.31.1 | Analysis and Synthesis of physical feature and socio-economic data |  | 50d? | 2012-07-16 | 2012-09-25 | 11, 62FS-10d | 53d | 0d | start no earlier than 2012-04-18 | Taufique; Akhtar; Fazlul; Habib; Mahamud; Statistician; Yearunnessa | 2800h | 187,500 |
| 68 | 15.31.2 | Integration of computed disaster related data into planning processes |  | 40d? | 2012-08-06 | 2012-10-03 | 13 | 22.38d | 0d | start no earlier than 2012-07-15 | Yearunnessa; Akhtar; Fazlul; Environmetal Expert; GIS/RS Expert; Jr.GIS/RS Expert; CADD Operator; Geologist; Taufique | 2880h | 750,000 |
| 69 | 15.31.3 | Draft structure plan |  | 80d? | 2012-08-21 | 2012-12-12 | 67FS-55d, 68FS-30d | 22.38d | 0d | start no earlier than 2012-07-30 | Taufique; Akhtar; CADD Operator; Environmetal Expert; Fazlul; Geologist; GIS/RS Expert; Jr.GIS/RS Expert; Tariq; Transport planner; Urban Economist | 7040h | 2,040,000 |
| 70 | 15.31.4 | Participatory Rural/Urban Appraisal (PRA), session-04 |  | 5d? | 2012-09-30 | 2012-10-07 | 69FS-53d, 74SS-3d, 78SS-53d | 110.38d | 0d | start no earlier than 2012-09-09 | Yearunnessa; Akhtar; Fazlul; Participatory Expert; Shafique; Taufique | 240h | 18,750 |
| 71 | 15.31.5 | Planning workshop-01 |  | 5d? | 2012-10-07 | 2012-10-14 | 70 | 57.38d | 0d |  | Taufique; Akhtar; CDMP; Fazlul; Habib; Mahamud; Tariq | 280h |  |
| 72 | 15.31.6 | Final structure planning |  | 15d? | 2012-10-14 | 2012-11-04 | 71 | 57.38d | 0d |  | Tariq; Taufique; Transport planner; Urban Economist; Akhtar; Fazlul; Geologist; GIS/RS Expert; CADD Operator; Environmetal Expert; Jr.GIS/RS Expert | 1320h | 382,500 |
| 73 | 15.31.7 | Finalization of Structure Plan | milestone | 0d? | 2012-11-04 | 2012-11-04 | 72 | 216.38d |  |  |  |  |  |
| 74 | 15.31.8 | Draft Urban Area Plan |  | 60d? | 2012-10-03 | 2012-12-30 | 69SS+30d | 22.38d | 0d | start no earlier than 2012-05-03 | Akhtar; Fazlul; GIS/RS Expert; Environmetal Expert; Geologist; Jr.GIS/RS Expert; Tariq; Transport planner; Taufique; Urban Economist | 4800h | 1,305,000 |
| 75 | 15.31.9 | Planning workshop-02 |  | 5d? | 2012-12-30 | 2013-01-06 | 74 | 163.38d | 0d |  | Akhtar; Fazlul; Habib; Shafique; Tariq; Taufique; Yearunnessa; Mahamud; Mokles | 360h |  |
| 76 | 15.31.10 | Final Urban area Plan |  | 15d? | 2013-01-06 | 2013-01-27 | 75 | 163.38d | 0d |  | Urban Economist; Akhtar; Environmetal Expert; Fazlul; Geologist; GIS/RS Expert; Jr.GIS/RS Expert; CADD Operator; Transport planner; Taufique; Tariq | 1320h | 382,500 |
| 77 | 15.31.11 | Finlization of Urban Area Plan | milestone | 0d | 2013-01-27 | 2013-01-27 | 76 | 163.38d |  |  |  |  |  |
| 78 | 15.31.12 | Disaster focused land use plan of Mymensing municipality |  | 40d? | 2012-12-12 | 2013-02-10 | 74FS-10d | 22.38d | 0d | start no earlier than 2012-07-29 | Akhtar; Fazlul; Jr.GIS/RS Expert; GIS/RS Expert; Habib; Mahamud; Taufique; Tariq; Yearunnessa; Shafique | 3200h | 300,000 |
| 79 | 15.31.13 | Participatory Rural/Urban Appraisal (PRA), session-05 |  | 5d? | 2012-10-28 | 2012-11-04 | 78FS-73d, 80SS+22d | 216.38d |  | start no earlier than 2012-10-07 | Fazlul; Participatory Expert; Shafique; Taufique; Akhtar; Yearunnessa | 240h | 18,750 |
| 80 | 15.31.14 | Draft Action Area Plan |  | 50d? | 2012-09-23 | 2012-12-02 | 72SS-15d | 90.38d | 0d | start no earlier than 2012-09-05 |  |  |  |
| 81 | 15.31.15 | Planning workshop-03 |  | 5d? | 2012-12-02 | 2012-12-09 | 80 | 90.38d | 0d |  |  |  |  |
| 82 | 15.31.16 | Final Action area Plan |  | 20d? | 2012-12-09 | 2013-01-08 | 81 | 90.38d | 0d |  |  |  |  |
| 83 | 15.31.17 | Finalization of Action Area Plan | milestone | 0d | 2013-01-08 | 2013-01-08 | 82 | 170.38d | 0d |  |  |  |  |
| 84 | 15.31.18 | Composite Planning document for Mymensing Municipality area |  | 20d? | 2013-01-08 | 2013-02-05 | 82 | 90.38d | 15.38d |  |  |  |  |
| 85 | 15.31.19 | Public Hearing on composite planning document |  | 30d? | 2013-03-03 | 2013-04-16 | 84FS+1d | 75d | 0d | start no earlier than 2013-03-03 |  |  |  |
| 86 | 15.31.20 | Public Participation on Planning Process | milestone | 0d | 2013-04-16 | 2013-04-16 | 85 | 110d |  |  |  |  |  |
| 87 | 15.31.21 | Finalization of Composite Planning documents |  | 15d? | 2013-04-17 | 2013-05-07 | 85 | 75d | 0d |  |  |  |  |
| 88 | 15.31.22 | Completion of Planning Package | milestone | 0d | 2013-05-07 | 2013-05-07 | 87 | 95d |  |  |  |  |  |
| 89 | 15.31.23 | Preparation of Training Manual |  | 475d? | 2011-09-14 | 2013-08-01 | 115SS, 87FF | 13.38d | 0d | start no earlier than 2011-09-14 |  |  |  |
| 90 | 15.31.24 | Printing of Planning Documents |  | 15d? | 2013-08-01 | 2013-08-26 | 89 | 13.38d |  | start no earlier than 2012-12-20 |  |  |  |
| 91 | 15.31.25 | Preparing the Customized Web page for Mymensing Municipality |  | 465d? | 2011-10-05 | 2013-08-08 | 89FF+5d | 18.38d | 12.38d | start no earlier than 2011-10-05 | Consultanting Firm by UDD | 3720h |  |
| 92 | 15.31.26 | National Seminar on mainstreaming disaster management into land use planning |  | 5d? | 2013-08-29 | 2013-09-04 | 91 | 6d | 0d | start no earlier than 2013-08-29 | CDMP; UDD | 80h |  |
| 93 | 15.31.27 | Fulfillment of Agreement with CDMP II | milestone | 0d | 2013-09-04 | 2013-09-04 | 92 | 6d |  |  |  |  |  |

| ID | WBS | Task | Type | Duration | Start | Finish | Predecessors | Complete | Remaining | Total slack | Free slack | Constraint | Deadline |
| --- | --- | --- | --- | --- | --- | --- | --- | --- | --- | --- | --- | --- | --- |
| 94 | 16 | **Procurement Plan** |  | 624.38d? | 2011-03-20 A | 2013-09-12 |  | 10% | 562.28d? | 5d |  |  |  |
| 95 | 16.1 | Procurement of Stationaries |  | 40d | 2011-04-17 A | 2011-06-09 A |  | 100% |  |  |  | start no earlier than 2011-04-17 |  |
| 96 | 16.2 | Procurement of Hardware by UDD |  | 40d | 2011-04-17 A | 2011-06-09 A |  | 100% |  |  |  | start no earlier than 2011-04-17 |  |
| 97 | 16.3 | Procurement of Software by CDMP |  | 40d? | 2011-08-01 | 2011-10-03 |  |  |  | 494.38d |  | start no earlier than 2011-08-01 |  |
| 98 | 16.4 | Procurement of Satellite Image by CDMP |  | 18d? | 2011-08-01 | 2011-08-29 |  |  |  | 516.38d |  | finish no earlier than 2011-08-29 |  |
| 99 | 16.5 | Procurement of Mouza Map by UDD |  | 20d? | 2011-09-04 A | 2011-09-29 | 17SS | 50% | 10d? | 496.38d |  | finish no earlier than 2011-09-29 |  |
| 100 | 16.6 | Contractor Selection for Networking of UDD GIS Lab and Training Room |  | 40d? | 2011-09-25 | 2011-11-23 |  |  |  | 461.38d |  | start no earlier than 2011-09-25 |  |
| 101 | 16.7 | Hiring of GIS-RS Consultants for UDD official & staff by CDMP |  | 45d | 2011-07-21 | 2011-09-29 |  |  |  | 496.38d |  | finish no earlier than 2011-09-29 |  |
| 102 | 16.8 | Call for Tender for appointment of individual consultants by CDMP |  | 24d? | 2011-11-03 | 2011-12-12 |  |  |  | 255.38d | 0d | start no earlier than 2011-11-03 |  |
| 103 | 16.9 | Short Listing of individual consultants byCDMP |  | 5d? | 2011-12-19 | 2011-12-26 | 135SS |  |  | 255.38d | 0d | start no earlier than 2011-09-11 |  |
| 104 | 16.10 | Notification of Award for consultants byCDMP |  | 5d? | 2011-12-27 | 2012-01-02 | 103 |  |  | 255.38d | 0d | start no earlier than 2011-09-18 |  |
| 105 | 16.11 | Call for Tender and Hiring of Site Office at Mymensingh |  | 24d? | 2011-09-25 | 2011-10-27 |  |  |  | 148.38d | 0d | start no earlier than 2011-09-25 |  |
| 106 | 16.12 | Site Office rent by UDD |  | 240d | 2011-11-01 | 2013-02-17 | 105FS+2d |  |  | 148.38d |  | start no earlier than 2011-11-01 |  |
| 107 | 16.13 | Call for Tender and Hiring of Micro Bus at Mymensingh |  | 24d? | 2011-09-25 | 2011-10-27 |  |  |  | 237.38d | 0d | start no earlier than 2011-09-25 |  |
| 108 | 16.14 | Micro Bus rent by UDD |  | 240d? | 2011-11-01 | 2012-10-15 | 107 |  |  | 235.38d |  | start no earlier than 2011-11-01 |  |
| 109 | 16.15 | Purchase of furniture by UDD |  | 24d? | 2011-09-25 | 2011-10-27 |  |  |  | 472.38d | 0d | start no earlier than 2011-09-25 |  |
| 110 | 16.16 | Delivary of Furniture by the Contractor |  | 5d? | 2011-10-30 | 2011-11-03 | 109 |  |  | 472.38d |  | start no earlier than 2011-10-30 |  |
| 111 | 16.17 | Call for Tender for web firm by UDD |  | 30d? | 2011-10-03 | 2011-11-17 | 115FS+3d |  |  | 450.38d | 0d | start no earlier than 2011-10-03 |  |
| 112 | 16.18 | Short Listing & evaluation of Web firm by UDD |  | 10d? | 2011-11-20 | 2011-12-01 | 111 |  |  | 450.38d | 0d | finish no earlier than 2011-12-01 |  |
| 113 | 16.19 | Notification of Award for Web firm by UDD |  | 5d? | 2011-12-04 | 2011-12-11 | 112 |  |  | 450.38d |  | start no earlier than 2011-09-15 |  |
| 114 | 16.20 | **Reporting Schedule** |  | 624.38d? | 2011-03-20 A | 2013-09-12 |  | 10% | 563.52d? | 5d |  |  |  |
| 115 | 16.20.1 | Inception Report by UDD |  | 126d | 2011-03-20 A | 2011-09-20 A |  | 100% |  |  |  | start no earlier than 2011-03-20 | 2011-09-20 |
| 116 | 16.20.2 | Completion of Prepiratory Activities of UDD | milestone | 0d | 2011-09-20 | 2011-09-20 | 115 |  |  | 503.38d |  |  |  |
| 117 | 16.20.3 | Survey Report by CDMP |  | 120d? | 2011-11-22 | 2012-05-14 | 9SS+10d |  |  | 338.38d | 0d | start no earlier than 2011-11-01 |  |
| 118 | 16.20.4 | Compltion of Physical Feature Survey & Starting of Planning Activities | milestone | 0d? | 2012-05-14 | 2012-05-14 | 117 |  |  | 343.38d |  |  |  |
| 119 | 16.20.5 | Socio-Economic Survey Report by UDD |  | 75d? | 2012-03-08 | 2012-06-24 | 57SS+20d |  |  | 314d | 0d | start no earlier than 2011-11-01 |  |
| 120 | 16.20.6 | Identification of Socio-Economic Condition of the Study Area | milestone | 0d? | 2012-06-24 | 2012-06-24 | 119 |  |  | 314d |  |  |  |
| 121 | 16.20.7 | Report on Disaster measure (Earthquake)by CDMP |  | 76d? | 2012-05-21 | 2012-09-06 | 13SS+10d |  |  | 167.38d | 0d | start no earlier than 2011-09-01 |  |
| 122 | 16.20.8 | Identification Disaster Risk and Earthquake in particular of the Study Area | milestone | 0d? | 2012-09-06 | 2012-09-06 | 121 |  |  | 172.38d | 4d |  |  |
| 123 | 16.20.9 | Final Structure Plan Report by UDD |  | 90d? | 2012-09-12 | 2013-01-20 | 69SS+15d, 122 |  |  | 163.38d | 0d | start no earlier than 2012-08-14 |  |
| 124 | 16.20.10 | Completion of Structure Plan of the Study Area | milestone | 0d? | 2013-01-20 | 2013-01-20 | 123 |  |  | 168.38d |  |  |  |
| 125 | 16.20.11 | Final Urban Area Plan Report by UDD |  | 75d | 2012-10-31 | 2013-02-17 | 74SS+20d |  |  | 148.38d | 0d | finish no earlier than 2012-09-16 |  |
| 126 | 16.20.12 | Completion of Urban Area Plan of the Study Area | milestone | 0d? | 2013-02-17 | 2013-02-17 | 125 |  |  | 148.38d |  |  |  |
| 127 | 16.20.13 | Disaster and planning interface report by UDD |  | 100d? | 2012-08-21 | 2013-01-13 | 68SS+10d |  |  | 168.38d | 0d | start no earlier than 2012-07-15 |  |
| 128 | 16.20.14 | Completion of Integrating Disaster Risk Reduction in Urban Planning | milestone | 0d? | 2013-01-13 | 2013-01-13 | 127 |  |  | 173.38d |  |  |  |
| 129 | 16.20.15 | Final Action Area Plan Report by UDD |  | 80d | 2012-10-21 | 2013-02-12 | 80SS+20d |  |  | 151.38d | 0d | start no earlier than 2012-06-24 |  |
| 130 | 16.20.16 | Completion of Detailed Planning of the Study Area | milestone | 0d? | 2013-02-12 | 2013-02-12 | 129 |  |  | 151.38d |  |  |  |
| 131 | 16.20.17 | Training Manual by UDD |  | 470d? | 2011-10-02 | 2013-08-12 | 84FF+10d |  |  | 21.38d | 0d | start no earlier than 2011-10-02 |  |
| 132 | 16.20.18 | Training Manual on Disaster & Planning Interfacing | milestone | 0d? | 2013-08-12 | 2013-08-12 | 131 |  |  | 26.38d |  |  |  |

Notes:
- 95: Procurement Complete

| ID | WBS | Task | Duration | Start | Finish | Predecessors | Complete | Remaining | Total slack | Free slack | Constraint |
| --- | --- | --- | --- | --- | --- | --- | --- | --- | --- | --- | --- |
| 133 | 16.20.19 | **Activities of Different Committees** | 557.38d? | 2011-06-21 A | 2013-09-12 |  | 1% | 551.25d? | 5d |  |  |
| 134 | 16.20.19.1 | Tender Opening Committee (POC) for different consultant selection (7 nos.) | 5d? | 2011-12-12 | 2011-12-18 | 102FS-1d |  |  | 255.38d | 0d | start no earlier than 2011-09-26 |
| 135 | 16.20.19.2 | Tender Evaluation Committee (PEC) for different consultant selection (7 nos.) | 5d? | 2011-12-19 | 2011-12-26 | 134 |  |  | 255.38d | 0d |  |
| 136 | 16.20.19.3 | Technical Management Committee 1 (TMC1) | 5d? | 2012-05-16 | 2012-05-22 | 59FS+1d |  |  | 337d |  | start no earlier than 2011-10-26 |
| 137 | 16.20.19.4 | Technical Management Committee 2 (TMC2) | 5d? | 2013-01-09 | 2013-01-16 | 83FS+1d |  |  | 170.38d |  | start no earlier than 2012-08-26 |
| 138 | 16.20.19.5 | Technical Management Committee 3 (TMC3) | 5d? | 2013-04-18 | 2013-04-24 | 85FS+1d |  |  | 104d |  | start no earlier than 2012-11-19 |
| 139 | 16.20.19.6 | Quarterly Activity Review Committee 1 (QARC1) | 5d? | 2011-10-23 | 2011-10-27 |  |  |  | 477.38d |  | start no earlier than 2011-10-23 |
| 140 | 16.20.19.7 | Quarterly Activity Review Committee 2 (QARC2) | 5d? | 2012-02-19 | 2012-02-26 |  |  |  | 397d |  | start no earlier than 2012-02-19 |
| 141 | 16.20.19.8 | Quarterly Activity Review Committee 3 (QARC3) | 5d? | 2012-06-24 | 2012-06-28 |  |  |  | 310d |  | start no earlier than 2012-06-24 |
| 142 | 16.20.19.9 | Quarterly Activity Review Committee 4 (QARC4) | 5d? | 2012-10-21 | 2012-10-25 |  |  |  | 227d |  | start no earlier than 2012-10-21 |
| 143 | 16.20.19.10 | Quarterly Activity Review Committee 5 (QARC5) | 5d? | 2013-02-17 | 2013-02-24 |  |  |  | 144d |  | start no earlier than 2013-02-17 |
| 144 | 16.20.19.11 | Quarterly Activity Review Committee 6 (QARC6) | 5d? | 2013-06-23 | 2013-06-27 |  |  |  | 58d |  | start no earlier than 2013-06-23 |
| 145 | 16.20.19.12 | Quarterly Activity Review Committee 7 (QARC7) | 5d? | 2013-08-25 | 2013-08-29 |  |  |  | 10d |  | start no earlier than 2013-08-25 |
| 146 | 16.20.19.13 | National Seminar & Web Portal Opening | 5d? | 2013-09-08 | 2013-09-12 | 92SS |  |  | 0d |  | start no earlier than 2013-09-08 |
| 147 | 16.20.19.14 | **Mode of Payments** | 520.38d? | 2011-06-21 A | 2013-07-21 |  | 4% | 500.36d? | 37d |  |  |
| 148 | 16.20.19.14.1 | 1st Payment after Signing agreement | 1d | 2011-06-21 A | 2011-06-21 A | 3 | 100% |  |  |  | finish no earlier than 2011-06-21 |
| 149 | 16.20.19.14.2 | 2nd Payment after Inception Report | 5d? | 2011-09-21 | 2011-09-27 | 115 |  |  | 498.38d |  | start no earlier than 2011-09-19 |
| 150 | 16.20.19.14.3 | 3rd Payment before planning phases (Starting of rent of house, car, hiring of consultants etc) | 5d? | 2012-04-15 | 2012-04-19 | 105FS-35d, 107FS-35d, 109FS-35d |  |  | 354d |  | finish no earlier than 2012-04-19 |
| 151 | 16.20.19.14.4 | 4th Payment (different type of survey, administrative and contingency) | 5d? | 2012-05-27 | 2012-05-31 | 19, 57FS+1d |  |  | 325d |  | finish no earlier than 2012-05-31 |
| 152 | 16.20.19.14.5 | 5th Payment(Printing Paper,Cartages,Toners,Offset paper,Accessories etc. for planning Administrative cost and Contingency. | 5d? | 2013-01-07 | 2013-01-14 | 75FS+1d |  |  | 167.38d |  | finish no earlier than 2013-01-01 |
| 153 | 16.20.19.14.6 | 6th Payment Printing of Plan Book, National seminar. | 5d? | 2013-07-15 | 2013-07-21 | 85FS+5d |  |  | 37d |  | finish no earlier than 2013-07-21 |
